# 03-8083 schedule

Schedule from MS Project, 2003-11-24 to 2004-03-24, A marks actual dates.

## Calendars

- Standard: Mon-Fri 08:00-12:00, 13:00-17:00; Sat-Sun off. Exceptions (off unless hours are given): 2003-12-24 to 2004-01-02.

## Schedule

| ID | WBS | Task | Duration | Start | Finish | Predecessors | Complete | Remaining | Baseline start | Baseline finish | Baseline duration | Total slack | Free slack | Constraint |
| --- | --- | --- | --- | --- | --- | --- | --- | --- | --- | --- | --- | --- | --- | --- |
| 1 | 1 | Kick-off Meeting | 1d | 2003-11-24 A | 2003-11-24 A |  | 100% |  | 2003-11-24 | 2003-11-24 | 1d |  |  |  |
| 2 | 2 | Forming Evaluation | 7d | 2003-11-25 A | 2003-12-03 A | 1 | 100% |  | 2003-11-24 | 2003-11-24 | 1d |  |  |  |
| 3 | 3 | 1.7 Generate BOM for die rib assemblies and PVVS Segments and Order | 1d | 2003-12-04 A | 2003-12-04 A | 2 | 100% |  | 2003-11-24 | 2003-11-24 | 1d |  |  |  |
| 4 | 4 | 1.8 Material Delivery for Die Enclosures and PVVS Segments | 30d | 2003-11-28 A | 2004-01-20 |  | 95% | 1.5d | 2003-11-24 | 2003-11-24 | 1d | 32.6d | 1d | finish no earlier than 2004-01-20 |
| 5 | 5 | **1.9 Fabricate Die A Rib Assembly** | 33.5d | 2003-12-18 A | 2004-02-13 |  | 61% | 12.92d |  |  |  | 28d |  |  |
| 6 | 5.1 | 1.9.3 5 axis waterjet cut die ribs for Die A | 19d | 2003-12-18 A | 2004-01-23 |  | 90% | 1.9d |  |  |  | 31d | 0d | finish no earlier than 2004-01-23 |
| 7 | 5.2 | 1.9.7 Inspection of Die Ribs using CMM | 6d | 2004-01-26 A | 2004-02-02 | 6 | 25% | 4.5d |  |  |  | 29.5d | 0d |  |
| 8 | 5.3 | Drill and Tap Holes in Die Ribs | 3d | 2004-02-03 A | 2004-02-05 | 7 | 50% | 1.5d |  |  |  | 28d | 0d |  |
| 9 | 5.4 | 1.9.8 Machine complete 3 wall enclosure for Die A | 6d | 2004-01-22 A | 2004-01-29 | 4 | 90% | 0.6d |  |  |  | 31d | 0d | start no earlier than 2004-01-22 |
| 10 | 5.5 | Machine Rib Reinforcements/Braces for Die A | 2d | 2004-01-30 | 2004-02-02 | 9 |  |  |  |  |  | 31d | 3d |  |
| 11 | 5.6 | 1.9.14 Assemble die and inspect | 2d | 2004-02-06 | 2004-02-09 | 10, 8 |  |  |  |  |  | 28d | 0d |  |
| 12 | 5.7 | 1.9.17 Lightly tack weld Scab plate, test form, inspect, full tack/plug weld and inspect | 2d | 2004-02-10 | 2004-02-11 | 11 |  |  |  |  |  | 28d | 0d | start no earlier than 2003-12-09 |
| 13 | 5.8 | 1.9.23 locate/place ref points on die rib assembly | 0.5d | 2004-02-12 | 2004-02-12 | 12 |  |  |  |  |  | 28d | 0d |  |
| 14 | 5.9 | 1.9.24 Final Machine precision locking device for press | 1d | 2004-02-12 | 2004-02-13 | 13 |  |  |  |  |  | 28d |  |  |
| 15 | 6 | **1.10 Form Segment A** | 9.5d | 2004-02-13 | 2004-02-26 |  |  |  |  |  |  | 19d |  |  |
| 16 | 6.1 | 1.10.1 Plasma Cut to Pre-cut Segment Oversized | 1d | 2004-02-13 | 2004-02-13 |  |  |  |  |  |  | 19d | 0d | start no earlier than 2004-02-13 |
| 17 | 6.2 | 1.10.3 Form Segment and stress relieve with Male / Female Die | 2d | 2004-02-16 | 2004-02-17 | 16 |  |  |  |  |  | 19d | 0d |  |
| 18 | 6.3 | Inspect Segment using CMM | 1d | 2004-02-18 | 2004-02-18 | 17 |  |  |  |  |  | 19d | 0d |  |
| 19 | 6.4 | 1.10.5 Locate and Place Ref points on segment with CMM | 1d | 2004-02-19 | 2004-02-19 | 18 |  |  |  |  |  | 19d | 0d |  |
| 20 | 6.5 | 1.10.7 Stress Relieve if Necessary | 1d | 2004-02-20 | 2004-02-20 | 19 |  |  |  |  |  | 19d | 0d |  |
| 21 | 6.6 | 1.10.8 Scribe/Mark Segment Edges using CMM/Model and machine to size | 1d | 2004-02-23 | 2004-02-23 | 20 |  |  |  |  |  | 19d | 0d |  |
| 22 | 6.7 | 1.10.12 Inspect with CMM and Inspect Segment Thickness | 0.5d | 2004-02-24 | 2004-02-24 | 21 |  |  |  |  |  | 19d | 0d |  |
| 23 | 6.8 | Machine to size | 2d | 2004-02-24 | 2004-02-26 | 22 |  |  |  |  |  | 19d |  |  |
| 24 | 7 | **1.11 Repeat 1.9 and 1.10 for segment B** | 23.5d | 2004-01-26 | 2004-02-26 |  |  |  |  |  |  | 0d |  |  |
| 25 | 7.1 | Order Die Enclosure Material and cut to rough size | 5d | 2004-01-26 | 2004-01-30 |  |  |  |  |  |  | 6d | 0d | finish no earlier than 2004-01-30 |
| 26 | 7.2 | 1.9.3 5 axis waterjet cut die ribs for Die B | 10d | 2004-01-28 | 2004-02-10 |  |  |  |  |  |  | 0d |  | start no earlier than 2004-01-28 |
| 27 | 7.3 | 1.9.7 Inspection of Die Ribs using CMM | 3d | 2004-02-11 | 2004-02-13 | 26 |  |  |  |  |  | 0d |  | start no earlier than 2004-01-19 |
| 28 | 7.4 | Drill and Tap Holes in Die Ribs | 3d | 2004-02-16 | 2004-02-18 | 27 |  |  |  |  |  | 0d |  |  |
| 29 | 7.5 | 1.9.8 Machine complete 3 wall enclosure for Die B | 6d | 2004-02-02 | 2004-02-09 | 25 |  |  |  |  |  | 6d | 0d |  |
| 30 | 7.6 | Machine Rib Reinforcements/Braces for Die B | 1d | 2004-02-16 | 2004-02-16 | 29, 27 |  |  |  |  |  | 2d |  |  |
| 31 | 7.7 | 1.9.14 Assemble die and inspect | 2d | 2004-02-19 | 2004-02-20 | 30, 28 |  |  |  |  |  | 0d |  |  |
| 32 | 7.8 | 1.9.17 Lightly tack weld Scab plate, test form, inspect, full tack/plug weld and inspect | 2d | 2004-02-23 | 2004-02-24 | 31 |  |  |  |  |  | 0d |  | start no earlier than 2003-12-09 |
| 33 | 7.9 | 1.9.23 locate/place ref points on die rib assembly | 0.5d | 2004-02-25 | 2004-02-25 | 32 |  |  |  |  |  | 0d |  |  |
| 34 | 7.10 | 1.9.24 Final Machine precision locking device for press | 1d | 2004-02-25 | 2004-02-26 | 33 |  |  |  |  |  | 0d |  |  |

| ID | WBS | Task | Duration | Start | Finish | Predecessors | Total slack | Free slack | Constraint |
| --- | --- | --- | --- | --- | --- | --- | --- | --- | --- |
| 35 | 8 | **1.11 Repeat 1.9 and 1.10 for segment C** | 15.5d | 2004-02-10 | 2004-03-02 |  | 11.5d |  |  |
| 36 | 8.1 | 1.9.3 5 axis waterjet cut die ribs for Die C | 5d | 2004-02-11 | 2004-02-17 | 26 | 11.5d | 0d |  |
| 37 | 8.2 | 1.9.7 Inspection of Die Ribs using CMM | 1d | 2004-02-18 | 2004-02-18 | 36 | 11.5d | 0d |  |
| 38 | 8.3 | Drill and Tap Holes in Die Ribs | 3d | 2004-02-19 | 2004-02-23 | 37 | 11.5d | 0d |  |
| 39 | 8.4 | 1.9.8 Machine complete 3 wall enclosure for Die C | 6d | 2004-02-10 | 2004-02-17 | 29 | 14.5d | 0d |  |
| 40 | 8.5 | Machine Rib Reinforcements/Braces for Die C | 1d | 2004-02-18 | 2004-02-18 | 39 | 14.5d | 3d |  |
| 41 | 8.6 | 1.9.14 Assemble die and inspect | 2d | 2004-02-24 | 2004-02-25 | 40, 38 | 11.5d | 0d |  |
| 42 | 8.7 | 1.9.17 Lightly tack weld Scab plate, test form, inspect, full tack/plug weld and inspect | 2d | 2004-02-26 | 2004-02-27 | 41 | 11.5d | 0d | start no earlier than 2003-12-09 |
| 43 | 8.8 | 1.9.23 locate/place ref points on die rib assembly | 0.5d | 2004-03-01 | 2004-03-01 | 42 | 11.5d | 0d |  |
| 44 | 8.9 | 1.9.24 Final Machine precision locking device for press | 1d | 2004-03-01 | 2004-03-02 | 43 | 11.5d | 0d |  |
| 45 | 9 | **1.10 Form Segment B** | 9.5d | 2004-02-26 | 2004-03-10 |  | 0d |  |  |
| 46 | 9.1 | 1.10.1 Plasma Cut to Pre-cut Segment Oversized | 1d | 2004-02-26 | 2004-02-27 | 34 | 0d |  |  |
| 47 | 9.2 | 1.10.3 Form Segment and stress relieve with Mail/Female Die | 2d | 2004-02-27 | 2004-03-02 | 46 | 0d |  |  |
| 48 | 9.3 | Inspect Segment using CMM | 1d | 2004-03-02 | 2004-03-03 | 47 | 0d |  |  |
| 49 | 9.4 | 1.10.5 Locate and Place Ref points on segment with CMM | 1d | 2004-03-03 | 2004-03-04 | 48 | 0d |  |  |
| 50 | 9.5 | 1.10.7 Stress Relieve if Necessary | 1d | 2004-03-04 | 2004-03-05 | 49 | 0d |  |  |
| 51 | 9.6 | 1.10.8 Scribe/Mark Segment Edges using CMM/Model and machine to size | 1d | 2004-03-05 | 2004-03-08 | 50 | 0d |  |  |
| 52 | 9.7 | 1.10.12 Inspect with CMM and Inspect Segment Thickness | 0.5d | 2004-03-08 | 2004-03-08 | 51 | 0d |  |  |
| 53 | 9.8 | Machine to size | 2d | 2004-03-09 | 2004-03-10 | 52 | 9.5d |  |  |
| 54 | 10 | **1.10 Form Segment C** | 9.5d | 2004-03-02 | 2004-03-15 |  | 3.5d |  |  |
| 55 | 10.1 | 1.10.1 Plasma Cut to Pre-cut Segment Oversized | 1d | 2004-03-02 | 2004-03-02 |  | 3.5d | 0d | start no earlier than 2004-03-02 |
| 56 | 10.2 | 1.10.3 Form Segment and stress relieve with Mail/Female Die | 2d | 2004-03-03 | 2004-03-04 | 55 | 3.5d | 0d |  |
| 57 | 10.3 | Inspect Segment using CMM | 1d | 2004-03-05 | 2004-03-05 | 56 | 3.5d | 0d |  |
| 58 | 10.4 | 1.10.5 Locate and Place Ref points on segment with CMM | 1d | 2004-03-08 | 2004-03-08 | 57 | 3.5d | 0d |  |
| 59 | 10.5 | 1.10.7 Stress Relieve if Necessary | 1d | 2004-03-09 | 2004-03-09 | 58 | 3.5d | 0d |  |
| 60 | 10.6 | 1.10.8 Scribe/Mark Segment Edges using CMM/Model and machine to size | 1d | 2004-03-10 | 2004-03-10 | 59 | 3.5d | 0d |  |
| 61 | 10.7 | 1.10.12 Inspect with CMM and Inspect Segment Thickness | 0.5d | 2004-03-11 | 2004-03-11 | 60 | 3.5d | 0d |  |
| 62 | 10.8 | Machine to size | 2d | 2004-03-11 | 2004-03-15 | 61 | 7d |  |  |
| 63 | 11 | Assemble Jigs and Figuring for Assembly | 2d | 2004-03-09 | 2004-03-10 | 52 | 0d |  |  |

| ID | WBS | Task | Duration | Start | Finish | Predecessors | Complete | Remaining | Baseline start | Baseline finish | Baseline duration | Total slack | Free slack | Constraint |
| --- | --- | --- | --- | --- | --- | --- | --- | --- | --- | --- | --- | --- | --- | --- |
| 64 | 12 | **Weld Segments** | 5d | 2004-03-11 | 2004-03-17 |  |  |  |  |  |  | 0d |  |  |
| 65 | 12.1 | 2.4 Mount A and B Segments together, inspect then tack , then inspect with CMM | 1d | 2004-03-11 | 2004-03-11 | 63 |  |  |  |  |  | 0d |  |  |
| 66 | 12.2 | 2.10 Full weld of segments | 1d | 2004-03-12 | 2004-03-12 | 65 |  |  |  |  |  | 0d |  |  |
| 67 | 12.3 | 2.10 Inspect weld, inspect with CMM, grind welds and polish | 1d | 2004-03-15 | 2004-03-15 | 66 |  |  |  |  |  | 0d |  |  |
| 68 | 12.4 | 2.14 Inspect with CMM for distortion | 1d | 2004-03-16 | 2004-03-16 | 67 |  |  |  |  |  | 0d |  |  |
| 69 | 12.5 | Weld Segment C in place | 1d | 2004-03-17 | 2004-03-17 | 68, 61 |  |  |  |  |  | 0d |  |  |
| 70 | 13 | 2.15 Clean and Surface Finish , and inspect | 1d | 2004-03-18 | 2004-03-18 | 69 |  |  |  |  |  | 0d |  |  |
| 71 | 14 | 3.5 Machine port extension tube | 1d | 2004-03-02 | 2004-03-03 | 44 |  |  |  |  |  | 11.5d |  |  |
| 72 | 15 | 3.9 Mount and tack weld tube and inspect before full weld | 0.5d | 2004-03-19 | 2004-03-19 | 71, 70 |  |  |  |  |  | 0d |  |  |
| 73 | 16 | 3.19 Install and inspect flange then leak check | 0.5d | 2004-03-19 | 2004-03-19 | 72 |  |  |  |  |  | 0d |  |  |
| 74 | 17 | 3.26 Cut off port extension and inspect | 0.5d | 2004-03-22 | 2004-03-22 | 73 |  |  |  |  |  | 0d |  |  |
| 75 | 18 | 3.28 Cut hole in PVVS and inspect | 0.5d | 2004-03-22 | 2004-03-22 | 74 |  |  |  |  |  | 0d |  |  |
| 76 | 19 | 3.32 Stitch weld port reinforcement and port extension and inspect | 0.5d | 2004-03-23 | 2004-03-23 | 75 |  |  |  |  |  | 0d |  |  |
| 77 | 20 | PVVS final inspections | 1d | 2004-03-23 | 2004-03-24 | 76 |  |  |  |  |  | 0d |  |  |
| 79 | 21 | **Parallel Port Process Development project** | 26d | 2004-01-15 A | 2004-02-19 |  | 48% | 13.59d |  |  |  | 23.5d |  |  |
| 80 | 21.1 | Purchase Material for skin | 7d | 2004-01-15 A | 2004-01-23 A |  | 100% |  | 2004-01-15 | 2004-01-23 | 7d |  |  | finish no earlier than 2004-01-23 |
| 81 | 21.2 | Purchase material for port | 8d | 2004-01-15 A | 2004-01-26 A |  | 100% |  | 2004-01-15 | 2004-01-23 | 7d |  |  | finish no earlier than 2004-01-26 |
| 82 | 21.3 | Locate 2 axis bending | 6d | 2004-01-16 A | 2004-01-23 A |  | 100% |  | 2004-01-16 | 2004-01-23 | 6d |  |  | finish no earlier than 2004-01-23 |
| 83 | 21.4 | Press | 4d | 2004-01-26 | 2004-01-29 | 82 |  |  | 2004-01-26 | 2004-02-03 | 7d | 23.5d | 0d | start no earlier than 2004-01-26 |
| 84 | 21.5 | Digitize with Faro | 2d | 2004-01-30 | 2004-02-02 | 83 |  |  | 2004-02-04 | 2004-02-05 | 2d | 23.5d | 0d |  |
| 85 | 21.6 | Fab Port | 3d | 2004-01-27 | 2004-01-29 | 81 |  |  | 2004-01-26 | 2004-01-28 | 3d | 37.5d | 0d | start no earlier than 2004-01-27 |
| 86 | 21.7 | Digitize Port | 1d | 2004-01-30 | 2004-01-30 | 85 |  |  | 2004-01-29 | 2004-01-30 | 2d | 37.5d |  |  |
| 87 | 21.8 | Design of Off-normal configurations (port to surface) | 3d | 2004-02-03 | 2004-02-05 | 84 |  |  | 2004-02-06 | 2004-02-10 | 3d | 23.5d | 0d |  |
| 88 | 21.9 | Develop model of port | 2d | 2004-02-06 | 2004-02-09 | 87 |  |  | 2004-02-11 | 2004-02-13 | 3d | 23.5d | 0d |  |

| ID | WBS | Task | Duration | Start | Finish | Predecessors | Baseline start | Baseline finish | Baseline duration | Total slack | Free slack |
| --- | --- | --- | --- | --- | --- | --- | --- | --- | --- | --- | --- |
| 89 | 21.10 | **Weld port to surface** | 4d | 2004-02-10 | 2004-02-13 |  | 2004-02-16 | 2004-02-20 | 5d | 23.5d |  |
| 90 | 21.10.1 | design/build fixturing | 2d | 2004-02-10 | 2004-02-11 | 88 | 2004-02-16 | 2004-02-18 | 3d | 23.5d | 0d |
| 91 | 21.10.2 | check location with Faro Arm prior to Weld | 1d | 2004-02-12 | 2004-02-12 | 90 | 2004-02-19 | 2004-02-19 | 1d | 23.5d | 0d |
| 92 | 21.10.3 | weld | 1d | 2004-02-13 | 2004-02-13 | 91 | 2004-02-20 | 2004-02-20 | 1d | 23.5d | 0d |
| 93 | 21.11 | Inspect configuration | 1d | 2004-02-16 | 2004-02-16 | 92 | 2004-02-23 | 2004-02-23 | 1d | 23.5d | 0d |
| 94 | 21.12 | Cut/remove port per procedure | 3d | 2004-02-17 | 2004-02-19 | 93 | 2004-02-24 | 2004-02-24 | 1d | 23.5d |  |
